# MoveOfficeExporting

Schedule from MS Project, 2025-01-06 to 2025-02-20, status date 2019-01-31, costs in $, A marks actual dates.
Microsoft

## Calendars

- Standard: Mon-Fri 08:00-12:00, 13:00-17:00; Sat-Sun off.

## Schedule

| ID | WBS | Task | Type | Duration | Start | Finish | Predecessors | Complete | Remaining | Baseline start | Baseline finish | Baseline duration | Total slack | Constraint | Deadline | Cost | Baseline cost | Actual cost |
| --- | --- | --- | --- | --- | --- | --- | --- | --- | --- | --- | --- | --- | --- | --- | --- | --- | --- | --- |
| 1 | 1 | **Pre-work** |  | 5.25d | 2025-01-06 A | 2025-01-13 A |  | 100% |  | 2025-01-06 | 2025-01-09 | 3.62d |  |  |  |  |  |  |
| 2 | 1.1 | Get Fit-out quotes |  | 2d | 2025-01-06 A | 2025-01-07 A |  | 100% |  | 2025-01-06 | 2025-01-07 | 2d |  |  |  |  |  |  |
| 3 | 1.2 | Get Moving Company Quotes |  | 1d | 2025-01-08 A | 2025-01-08 A | 2 | 100% |  | 2025-01-08 | 2025-01-08 | 1d |  |  |  |  |  |  |
| 4 | 1.3 | Evaluate and Accept Quotes |  | 5h | 2025-01-09 A | 2025-01-09 A | 3 | 100% |  | 2025-01-09 | 2025-01-09 | 3h |  |  |  |  |  |  |
| 5 | 1.4 | Confirm Moving Day |  | 2h | 2025-01-13 A | 2025-01-13 A | 4 | 100% |  | 2025-01-09 | 2025-01-09 | 2h |  | finish no later than 2025-01-10 | 2025-01-10 |  |  |  |
| 6 | 2 | **Fit Out New Premises** |  | 7d | 2025-01-13 A | 2025-01-21 A | 1 | 100% |  | 2025-01-09 | 2025-01-21 | 7.5d |  |  |  | 10,100 | 10,100 | 10,100 |
| 7 | 2.1 | Power |  | 0.5d | 2025-01-13 A | 2025-01-13 A |  | 100% |  | 2025-01-09 | 2025-01-10 | 0.5d |  |  |  | 100 | 100 | 100 |
| 8 | 2.2 | Cabling |  | 4d | 2025-01-13 A | 2025-01-16 A | 7 | 100% |  | 2025-01-10 | 2025-01-16 | 4d |  |  |  | 5,000 | 5,000 | 5,000 |
| 9 | 2.3 | Decorating |  | 1w | 2025-01-15 A | 2025-01-21 A | 8FS-5% | 100% |  | 2025-01-14 | 2025-01-21 | 1w |  |  |  | 5,000 | 5,000 | 5,000 |
| 10 | 3 | **Packing** |  | 6d | 2025-01-22 A | 2025-01-29 A | 6 | 100% |  | 2025-01-21 | 2025-01-29 | 6d |  |  |  | 100 | 100 | 100 |
| 11 | 3.1 | Get Boxes |  | 1d | 2025-01-22 A | 2025-01-22 A |  | 100% |  | 2025-01-21 | 2025-01-22 | 1d |  |  |  | 100 | 100 | 100 |
| 12 | 3.2 | Pack boxes |  | 1w | 2025-01-23 A | 2025-01-29 A | 11 | 100% |  | 2025-01-22 | 2025-01-29 | 1w |  |  |  |  |  |  |
| 13 | 3.3 | Make Inventory |  | 1w | 2025-01-23 A | 2025-01-29 A | 12SS | 100% |  | 2025-01-22 | 2025-01-29 | 1w |  |  |  |  |  |  |
| 14 | 4 | Transport Boxes |  | 1ed | 2025-01-30 A | 2025-01-31 | 10 | 8% | 0.92ed | 2025-01-29 | 2025-01-30 | 1ed | 0d |  |  |  |  |  |
| 15 | 5 | **Unpacking** |  | 15d | 2025-01-31 | 2025-02-20 | 14 |  |  | 2025-01-30 | 2025-02-20 | 15d | 0d |  |  |  |  |  |
| 16 | 5.1 | Unpack Boxes |  | 1w | 2025-01-31 | 2025-02-06 |  |  |  | 2025-01-30 | 2025-02-06 | 1w | 0d |  |  |  |  |  |
| 17 | 5.2 | Install Equipment |  | 1w | 2025-02-07 | 2025-02-13 | 16 |  |  | 2025-02-06 | 2025-02-13 | 1w | 0d |  |  |  |  |  |
| 18 | 5.3 | Check Inventory |  | 1w | 2025-02-14 | 2025-02-20 | 17 |  |  | 2025-02-13 | 2025-02-20 | 1w | 0d |  |  |  |  |  |
| 19 | 6 | Move In | milestone | 0d | 2025-02-20 | 2025-02-20 | 15 |  |  | 2025-02-20 | 2025-02-20 | 0d | 0d |  |  |  |  |  |
