# ReportResourcesPractice

Schedule from MS Project, 2025-01-06 to 2025-02-06, status date 2010-01-28, costs in $, A marks actual dates.
Microsoft

## Calendars

- Standard: Mon-Fri 08:00-12:00, 13:00-17:00; Sat-Sun off.

## Resources

| Resource | Group | Unit | Rate | Cost per use |
| --- | --- | --- | --- | --- |
| Manager | Internal |  | 48.08 |  |
| Manager’s PA | Internal |  | 72.12 |  |
| Techies | Internal |  | 100 |  |
| Moving Company | Contractor |  |  | 5000 |
| Decorators | Contractor |  |  | 5000 |
| Boxes | Consumables | Each | 5 |  |
| Travel Expenses | Costs |  |  |  |

## Schedule

| ID | WBS | Task | Type | Duration | Start | Finish | Predecessors | Complete | Remaining | Baseline start | Baseline finish | Baseline duration | Total slack | Resources | Work | Actual work | Cost | Baseline cost | Actual cost |
| --- | --- | --- | --- | --- | --- | --- | --- | --- | --- | --- | --- | --- | --- | --- | --- | --- | --- | --- | --- |
| 1 | 1 | **Pre-work** |  | 3.62d | 2025-01-06 A | 2025-01-09 A |  | 100% |  | 2010-01-04 | 2010-01-07 | 3.62d |  |  | 25h | 25h | 1,730.77 | 1,730.77 | 1,730.77 |
| 2 | 1.1 | Get Fit-out quotes |  | 2d | 2025-01-06 A | 2025-01-07 A |  | 100% |  | 2010-01-04 | 2010-01-05 | 2d |  | Manager’s PA | 16h | 16h | 1,153.85 | 1,153.85 | 1,153.85 |
| 3 | 1.2 | Get Moving Company Quotes |  | 1d | 2025-01-08 A | 2025-01-08 A | 2 | 100% |  | 2010-01-06 | 2010-01-06 | 1d |  | Manager’s PA [50%] | 4h | 4h | 288.46 | 288.46 | 288.46 |
| 4 | 1.3 | Evaluate and Accept Quotes |  | 3h | 2025-01-09 A | 2025-01-09 A | 3 | 100% |  | 2010-01-07 | 2010-01-07 | 3h |  | Manager | 3h | 3h | 144.23 | 144.23 | 144.23 |
| 5 | 1.4 | Confirm Moving Day |  | 2h | 2025-01-09 A | 2025-01-09 A | 4 | 100% |  | 2010-01-07 | 2010-01-07 | 2h |  | Manager’s PA | 2h | 2h | 144.23 | 144.23 | 144.23 |
| 6 | 2 | **Fit Out New Premises** |  | 7.5d | 2025-01-09 A | 2025-01-21 | 1 | 47% | 3.95d | 2010-01-07 | 2010-01-19 | 7.5d | 0d |  | 162h | 112h | 31,998.08 | 26,398.08 | 21,276.92 |
| 7 | 2.1 | Power |  | 0.5d | 2025-01-09 A | 2025-01-10 A |  | 100% |  | 2010-01-07 | 2010-01-08 | 0.5d |  | Techies | 4h | 4h | 700 | 500 | 700 |
| 8 | 2.2 | Cabling |  | 4d | 2025-01-10 A | 2025-01-16 A | 7 | 100% |  | 2010-01-08 | 2010-01-14 | 4d |  | Manager’s PA [25%]; Techies [300%] | 108h | 108h | 20,576.92 | 15,176.92 | 20,576.92 |
| 9 | 2.3 | Decorating |  | 1w | 2025-01-14 | 2025-01-21 | 8FS-5% |  |  | 2010-01-12 | 2010-01-19 | 1w | 0d | Manager’s PA [25%]; Decorators | 50h |  | 10,721.15 | 10,721.15 |  |
| 10 | 3 | **Packing** |  | 6d | 2025-01-21 | 2025-01-29 | 6 |  |  | 2010-01-19 | 2010-01-27 | 6d | 0d |  | 176h |  | 23,484.62 | 19,234.62 |  |
| 11 | 3.1 | Get Boxes |  | 1d | 2025-01-21 | 2025-01-22 |  |  |  | 2010-01-19 | 2010-01-20 | 1d | 0d | Boxes [20 Each]; Techies [200%] | 16h |  | 2,600 | 1,800 |  |
| 12 | 3.2 | Pack boxes |  | 1w | 2025-01-22 | 2025-01-29 | 11 |  |  | 2010-01-20 | 2010-01-27 | 1w | 0d | Techies [300%] | 120h |  | 18,000 | 14,550 |  |
| 13 | 3.3 | Make Inventory |  | 1w | 2025-01-22 | 2025-01-29 | 12SS |  |  | 2010-01-20 | 2010-01-27 | 1w | 0d | Manager’s PA | 40h |  | 2,884.62 | 2,884.62 |  |
| 14 | 4 | Transport Boxes |  | 1d | 2025-01-29 | 2025-01-30 | 10 |  |  | 2010-01-27 | 2010-01-28 | 1d | 0d | Moving Company | 8h |  | 5,000 | 5,000 |  |
| 15 | 5 | **Unpacking** |  | 5d | 2025-01-30 | 2025-02-06 | 14 |  |  | 2010-01-28 | 2010-02-04 | 5d | 0d |  | 160h |  | 20,884.62 | 20,884.62 |  |
| 16 | 5.1 | Unpack Boxes |  | 1w | 2025-01-30 | 2025-02-06 |  |  |  | 2010-01-28 | 2010-02-04 | 1w | 0d | Techies [150%] | 60h |  | 9,000 | 9,000 |  |
| 17 | 5.2 | Install Equipment |  | 1w | 2025-01-30 | 2025-02-06 | 16FF |  |  | 2010-01-28 | 2010-02-04 | 1w | 0d | Techies [150%] | 60h |  | 9,000 | 9,000 |  |
| 18 | 5.3 | Check Inventory |  | 1w | 2025-01-30 | 2025-02-06 | 17FF |  |  | 2010-01-28 | 2010-02-04 | 1w | 0d | Manager’s PA | 40h |  | 2,884.62 | 2,884.62 |  |
| 19 | 6 | Move In | milestone | 0d | 2025-02-06 | 2025-02-06 | 15 |  |  | 2010-02-04 | 2010-02-04 | 0d | 0d |  |  |  |  |  |  |
