# ResourceCostsPractice

Schedule from MS Project, 2025-01-06 to 2025-02-06, status date 2019-01-28, costs in $.
Microsoft

## Calendars

- Standard: Mon-Fri 08:00-12:00, 13:00-17:00; Sat-Sun off.

## Resources

| Resource | Group | Unit |
| --- | --- | --- |
| Manager | Internal |  |
| Manager’s PA | Internal |  |
| Techies | Internal |  |
| Moving Company | Contractor |  |
| Decorators | Contractor |  |
| Boxes | Consumables | Each |
| Travel Expenses | Costs |  |

## Schedule

| ID | WBS | Task | Type | Duration | Start | Finish | Predecessors | Total slack | Constraint | Deadline | Resources | Work | Cost |
| --- | --- | --- | --- | --- | --- | --- | --- | --- | --- | --- | --- | --- | --- |
| 1 | 1 | **Pre-work** |  | 3.62d | 2025-01-06 | 2025-01-09 |  | 0d |  |  |  | 25h |  |
| 2 | 1.1 | Get Fit-out quotes |  | 2d | 2025-01-06 | 2025-01-07 |  | 0d |  |  | Manager’s PA | 16h |  |
| 3 | 1.2 | Get Moving Company Quotes |  | 1d | 2025-01-08 | 2025-01-08 | 2 | 0d |  |  | Manager’s PA [50%] | 4h |  |
| 4 | 1.3 | Evaluate and Accept Quotes |  | 3h | 2025-01-09 | 2025-01-09 | 3 | 0d |  |  | Manager | 3h |  |
| 5 | 1.4 | Confirm Moving Day |  | 2h | 2025-01-09 | 2025-01-09 | 4 | 0d | finish no later than 2025-01-10 | 2025-01-10 | Manager’s PA | 2h |  |
| 6 | 2 | **Fit Out New Premises** |  | 7.5d | 2025-01-09 | 2025-01-21 | 1 | 0d |  |  |  | 158h | 10,100 |
| 7 | 2.1 | Power |  | 0.5d | 2025-01-09 | 2025-01-10 |  | 0d |  |  | Techies | 4h | 100 |
| 8 | 2.2 | Cabling |  | 4d | 2025-01-10 | 2025-01-16 | 7 | 0d |  |  | Manager’s PA [25%]; Techies [300%] | 104h | 5,000 |
| 9 | 2.3 | Decorating |  | 1w | 2025-01-14 | 2025-01-21 | 8FS-5% | 0d |  |  | Manager’s PA [25%]; Decorators | 50h | 5,000 |
| 10 | 3 | **Packing** |  | 6d | 2025-01-21 | 2025-01-29 | 6 | 0d |  |  |  | 176h | 100 |
| 11 | 3.1 | Get Boxes |  | 1d | 2025-01-21 | 2025-01-22 |  | 0d |  |  | Boxes [20 Each]; Techies [200%] | 16h | 100 |
| 12 | 3.2 | Pack boxes |  | 1w | 2025-01-22 | 2025-01-29 | 11 | 0d |  |  | Techies [300%] | 120h |  |
| 13 | 3.3 | Make Inventory |  | 1w | 2025-01-22 | 2025-01-29 | 12SS | 0d |  |  | Manager’s PA | 40h |  |
| 14 | 4 | Transport Boxes |  | 1d | 2025-01-29 | 2025-01-30 | 10 | 0d |  |  | Moving Company | 8h |  |
| 15 | 5 | **Unpacking** |  | 5d | 2025-01-30 | 2025-02-06 | 14 | 0d |  |  |  | 160h |  |
| 16 | 5.1 | Unpack Boxes |  | 1w | 2025-01-30 | 2025-02-06 |  | 0d |  |  | Techies [150%] | 60h |  |
| 17 | 5.2 | Install Equipment |  | 1w | 2025-01-30 | 2025-02-06 | 16FF | 0d |  |  | Techies [150%] | 60h |  |
| 18 | 5.3 | Check Inventory |  | 1w | 2025-01-30 | 2025-02-06 | 17FF | 0d |  |  | Manager’s PA | 40h |  |
| 19 | 6 | Move In | milestone | 0d | 2025-02-06 | 2025-02-06 | 15 | 0d |  |  |  |  |  |
