# SharedProject2Practice

Schedule from MS Project, 2025-01-06 to 2025-02-06, status date 2019-01-07, costs in $.
Microsoft

## Calendars

- Standard: Mon-Fri 08:00-12:00, 13:00-17:00; Sat-Sun off.

## Schedule

| ID | WBS | Task | Type | Duration | Start | Finish | Predecessors | Total slack | Deadline | Cost |
| --- | --- | --- | --- | --- | --- | --- | --- | --- | --- | --- |
| 1 | 1 | **Pre-work** |  | 3.62d | 2025-01-06 | 2025-01-09 |  | 0d |  |  |
| 2 | 1.1 | Get Fit-out quotes |  | 2d | 2025-01-06 | 2025-01-07 |  | 0d |  |  |
| 3 | 1.2 | Get Moving Company Quotes |  | 1d | 2025-01-08 | 2025-01-08 | 2 | 0d |  |  |
| 4 | 1.3 | Evaluate and Accept Quotes |  | 3h | 2025-01-09 | 2025-01-09 | 3 | 0d |  |  |
| 5 | 1.4 | Confirm Moving Day |  | 2h | 2025-01-09 | 2025-01-09 | 4 | 0d | 2025-01-09 |  |
| 6 | 2 | **Fit Out New Premises** |  | 7.5d | 2025-01-09 | 2025-01-21 | 1 | 0d |  | 10,100 |
| 7 | 2.1 | Power |  | 0.5d | 2025-01-09 | 2025-01-10 |  | 0d |  | 100 |
| 8 | 2.2 | Cabling |  | 4d | 2025-01-10 | 2025-01-16 | 7 | 0d |  | 5,000 |
| 9 | 2.3 | Decorating |  | 1w | 2025-01-14 | 2025-01-21 | 8FS-5% | 0d |  | 5,000 |
| 10 | 3 | **Packing** |  | 6d | 2025-01-21 | 2025-01-29 | 6 | 0d |  | 100 |
| 11 | 3.1 | Get Boxes |  | 1d | 2025-01-21 | 2025-01-22 |  | 0d |  | 100 |
| 12 | 3.2 | Pack boxes |  | 1w | 2025-01-22 | 2025-01-29 | 11 | 0d |  |  |
| 13 | 3.3 | Make Inventory |  | 1w | 2025-01-22 | 2025-01-29 | 12SS | 0d |  |  |
| 14 | 4 | Transport Boxes |  | 1d | 2025-01-29 | 2025-01-30 | 10 | 0d |  |  |
| 15 | 5 | **Unpacking** |  | 5d | 2025-01-30 | 2025-02-06 | 14 | 0d |  |  |
| 16 | 5.1 | Unpack Boxes |  | 1w | 2025-01-30 | 2025-02-06 |  | 0d |  |  |
| 17 | 5.2 | Install Equipment |  | 1w | 2025-01-30 | 2025-02-06 | 16FF | 0d |  |  |
| 18 | 5.3 | Check Inventory |  | 1w | 2025-01-30 | 2025-02-06 | 17FF | 0d |  |  |
| 19 | 6 | Move In | milestone | 0d | 2025-02-06 | 2025-02-06 | 15 | 0d |  |  |
